Schedule from MS Project, 2025-05-31 to 2026-05-14.
Microsoft

## Calendars

- Стандартный: Mon-Sun 09:00-13:00, 14:00-18:00.

## Schedule

| ID | WBS | Task | Duration | Start | Finish | Total slack | Constraint |
| --- | --- | --- | --- | --- | --- | --- | --- |
| 1 | 1 | **ВК ВС** | 348.88d | 2025-05-31 | 2026-05-14 | 0d |  |
| 2 | 1.1 | Внутренние системы водоснабжения и канализации. Крытый склад №1. 1632-2021-3.1-ВК | 50d | 2025-11-21 | 2026-01-10 | 124d | finish no earlier than 2026-01-10 |
| 3 | 1.2 | Внутренние системы водоснабжения и канализации. Крытый склад №2. 1632-2021-3.2-ВК | 45d | 2026-03-30 | 2026-05-14 | 0d | finish no earlier than 2026-05-14 |
| 4 | 1.3 | Крытые склады №1 и №2 Воздухоснабжение 1632-2021-3.1, 3.2-ВС | 26d | 2026-04-08 | 2026-05-04 | 10d | finish no earlier than 2026-05-04 |
| 5 | 1.4 | Купольный склад Внутренние системы водоснабжения и канализации 1632-2021-3.3-ВК | 20d | 2025-06-30 | 2025-07-19 | 298.88d | start no earlier than 2025-06-30 |
| 6 | 1.5 | Купольный склад Воздухоснабжение 1632-2021-3.3-ВС | 79d | 2025-05-31 | 2025-08-17 | 269.88d | start no earlier than 2025-05-31 |
| 7 | 1.6 | Внутренние системы водоснабжения и канализации. Конвейерная галерея №1. 1632-2021-2.1.1-ВК | 20d | 2025-09-13 | 2025-10-02 | 223.88d | start no earlier than 2025-09-13 |
| 8 | 1.7 | Конвейерная галерея №1 Воздухоснабжение 1632-2021-2.1.1-ВС | 20d | 2025-08-22 | 2025-09-10 | 245.88d | start no earlier than 2025-08-22 |
| 9 | 1.8 | Внутренние системы водоснабжения и канализации. Конвейерные галереи №2 и №7 в осях 8-14. 1632-2021-2.1.2, 2.1.7-ВК2 | 20d | 2025-10-23 | 2025-11-11 | 183.88d | start no earlier than 2025-10-23 |
| 10 | 1.9 | Внутренние системы водоснабжения и канализации. Конвейерные галереи №2 и №7 в осях 15-23. 1632-2021-2.1.2, 2.1.7-ВК3 | 20d | 2025-10-30 | 2025-11-18 | 176.88d | start no earlier than 2025-10-30 |
| 11 | 1.10 | Внутренние системы водоснабжения и канализации. Конвейерные галереи №2 и №7 в осях 1-7. 1632-2021-2.1.2, 2.1.7-ВК1 | 20d | 2025-10-16 | 2025-11-04 | 190.88d | start no earlier than 2025-10-16 |
| 12 | 1.11 | Конвейерная галерея №2 и конвейерная галерея №7. Воздухоснабжение 1632-2021-2.1.2, 2.1.7-ВС | 20d | 2025-10-30 | 2025-11-18 | 176.88d | start no earlier than 2025-10-30 |
| 13 | 1.12 | Внутренние системы водоснабжения и канализации. Конвейерная галерея №3. 1632-2021-2.1.3-ВК | 20d | 2025-10-10 | 2025-10-29 | 196.88d | start no earlier than 2025-10-10 |
| 14 | 1.13 | Конвейерная галерея №3 и приводная станция. Воздухоснабжение 1632-2021-2.1.3, 2.2.7-ВС | 29d | 2025-10-30 | 2025-11-28 | 167d | finish no earlier than 2025-11-28 |
| 15 | 1.14 | Внутренние системы водоснабжения и канализации. Конвейерная галерея №4. 1632-2021-2.1.4-ВК | 20d | 2025-06-09 | 2025-06-28 | 319.88d | start no earlier than 2025-06-09 |
| 16 | 1.15 | Конвейерная галерея №4 Воздухоснабжение 1632-2021-2.1.4-ВС | 20d | 2025-06-09 | 2025-06-28 | 319.88d | start no earlier than 2025-06-09 |
| 17 | 1.16 | Внутренние системы водоснабжения и канализации. Конвейерная галерея №5. 1632-2021-2.1.5-ВК | 25d | 2025-08-27 | 2025-09-20 | 235.88d | start no earlier than 2025-08-27 |
| 18 | 1.17 | Конвейерная галерея №6 Воздухоснабжение 1632-2021-2.1.6-ВС | 20d | 2025-11-22 | 2025-12-11 | 153.88d | start no earlier than 2025-11-22 |
| 19 | 1.18 | Внутренние системы водоснабжения и канализации. Пересыпная станция №4, Конвейерная галерея №6. 1632-2021-2.2.4, 2.1.6-ВК | 25d | 2025-10-20 | 2025-11-13 | 181.88d | start no earlier than 2025-10-20 |
| 20 | 1.19 | Внутренние системы водоснабжения и канализации. Конвейерная галерея №11. 1632-2021-2.1.11-ВК | 19d | 2025-09-02 | 2025-09-21 | 235d | finish no earlier than 2025-09-21 |
| 21 | 1.20 | Внутренние системы водоснабжения и канализации. Конвейерная галерея №12. 1632-2021-2.1.12-ВК | 25d | 2025-10-24 | 2025-11-17 | 177.88d | start no earlier than 2025-10-24 |
| 22 | 1.21 | Внутренние системы водоснабжения и канализации. Тоннель. Пересыпная станция №1. 1632-2021-2.1.0, 2.2.1-ВК | 51d | 2025-08-01 | 2025-09-21 | 235d | finish no earlier than 2025-09-21 |
| 23 | 1.22 | Конвейерная галерея №8, конвейерная галерея №9 и конвейерная галерея №10 1632-2021-2.1.8, 2.1.9, 2.1.10-ВС | 20d | 2025-09-06 | 2025-09-25 | 230.88d | start no earlier than 2025-09-06 |
| 24 | 1.23 | Конвейерная галерея №11 Воздухоснабжение 1632-2021-2.1.11-ВС | 20d | 2025-09-02 | 2025-09-21 | 234.88d | start no earlier than 2025-09-02 |
| 25 | 1.24 | Пересыпная станция №1 Воздухоснабжение 1632-2021-2.2.1-ВС | 45d | 2025-09-18 | 2025-11-02 | 193d | finish no earlier than 2025-11-02 |
| 26 | 1.25 | Внутренние системы водоснабжения и канализации. Пересыпная станция №2. 1632-2021-2.2.2-ВК | 36d | 2025-06-09 | 2025-07-14 | 303.88d | start no earlier than 2025-06-09 |
| 27 | 1.26 | Пересыпная станция №2 Воздухоснабжение 1632-2021-2.2.2-ВС | 36d | 2025-06-09 | 2025-07-14 | 303.88d | start no earlier than 2025-06-09 |
| 28 | 1.27 | Внутренние системы водоснабжения и канализации. Пересыпная станция №3. 1632-2021-2.2.3-ВК | 20d | 2025-08-30 | 2025-09-19 | 237d | finish no earlier than 2025-09-19 |
| 29 | 1.28 | Пересыпная станция №3 Воздухоснабжение 1632-2021-2.2.3-ВС | 20d | 2025-08-28 | 2025-09-17 | 239d | finish no earlier than 2025-09-17 |
| 30 | 1.29 | Пересыпная станция №4. Воздухоснабжение 1632-2021-2.2.4-ВС | 20d | 2025-10-16 | 2025-11-05 | 190d | finish no earlier than 2025-11-05 |
| 31 | 1.30 | Пересыпная станция №5 и конвейерная галерея №13 Воздухоснабжение 1632-2021-2.2.5, 2.1.13-ВС | 20d | 2025-09-29 | 2025-10-19 | 207d | finish no earlier than 2025-10-19 |
| 32 | 1.31 | Внутренние системы водоснабжения и канализации. Пересыпная станция №6. 1632-2021-2.2.6-ВК | 20d | 2025-10-24 | 2025-11-13 | 182d | finish no earlier than 2025-11-13 |
| 33 | 1.32 | Пересыпная станция №6 Воздухоснабжение 1632-2021-2.2.6-ВС | 20d | 2025-11-01 | 2025-11-21 | 174d | finish no earlier than 2025-11-21 |
| 34 | 1.33 | Внутренние системы водоснабжения и канализации. Станция разгрузки вагонов. Трансбордер. 1632-2021-1.1, 1.2-ВК | 45d | 2025-10-25 | 2025-12-09 | 156d | finish no earlier than 2025-12-09 |
| 35 | 1.34 | Станция разгрузки вагонов Воздухоснабжение 1632-2021-1.1-ВС | 49d | 2025-10-25 | 2025-12-13 | 152d | finish no earlier than 2025-12-13 |
| 36 | 1.35 | Внутренние системы водоснабжения и канализации. Приводная станция. 1632-2021-2.2.7-ВК | 24d | 2025-05-31 | 2025-06-24 | 324d | finish no earlier than 2025-06-24 |
| 37 | 1.36 | Внутренние системы водоснабжения и канализации. Пересыпная станция №5 и конвейерная галерея №13. 1632-2021-2.2.5, 2.1.13-ВК | 29d | 2025-09-30 | 2025-10-29 | 197d | finish no earlier than 2025-10-29 |
